# CBP_2010_P3A_Outside_Slack

Schedule from MS Project, 2010-01-04 to 2012-01-27, status date 2010-04-01, costs in $, A marks actual dates.
Home

## Calendars

- Standard: Mon-Fri 08:00-12:00, 13:00-17:00; Sat-Sun off. Exceptions (off unless hours are given): 2010-05-31, 2010-07-04 to 2010-07-05, 2010-09-06, 2010-11-25, 2010-12-24 to 2010-12-27, 2011-01-01, 2011-01-03, 2011-05-30, 2011-07-04, 2011-09-05, 2011-11-24, 2011-12-25 to 2011-12-27, 2012-01-01 to 2012-01-02.

## Resources

| Resource | Rate |
| --- | --- |
| Design | 100 |
| Development | 70 |
| Decumentation | 60 |
| Assembly/test | 70 |
| Purchasing | 40 |
| Xdevelopment | 120 |

## Schedule

| ID | WBS | Task | Duration | Start | Finish | Predecessors | Complete | Remaining | Baseline start | Baseline finish | Baseline duration | Total slack | Free slack | Resources | Work | Actual work | Cost | Baseline cost | Actual cost |
| --- | --- | --- | --- | --- | --- | --- | --- | --- | --- | --- | --- | --- | --- | --- | --- | --- | --- | --- | --- |
| 1 | 1 | **Conveyor Belt Project** | 526d | 2010-01-04 A | 2012-01-27 |  | 12% | 461.15d | 2010-01-04 | 2012-02-02 | 530d | 0d |  |  | 13912h | 1784h | 1,047,280 | 1,051,200 | 151,680 |
| 2 | 1.1 | **Hardware** | 435d | 2010-02-09 A | 2011-10-24 |  | 14% | 373.1d | 2010-02-08 | 2011-10-28 | 440d | 5d |  |  | 4120h | 592h | 319,600 | 326,400 | 50,320 |
| 3 | 1.1.1 | Hardware specifications | 45d | 2010-02-09 A | 2010-04-12 | 24 | 82% | 8d | 2010-02-08 | 2010-04-16 | 50d | 0d |  | Development; Design | 720h | 592h | 61,200 | 68,000 | 50,320 |
| 4 | 1.1.2 | Hardware design | 70d | 2010-04-13 | 2010-07-21 | 3 |  |  | 2010-04-19 | 2010-07-27 | 70d | 0d |  | Design; Development | 1120h |  | 95,200 | 95,200 |  |
| 5 | 1.1.3 | Hardware documentation | 30d | 2010-07-22 | 2010-09-01 | 4 |  |  | 2010-07-28 | 2010-09-08 | 30d | 0d |  | Decumentation; Design | 480h |  | 38,400 | 38,400 |  |
| 6 | 1.1.4 | Prototypes | 80d | 2010-11-12 | 2011-03-09 | 25 |  |  | 2010-11-18 | 2011-03-15 | 80d | 50d |  | Assembly/test; Development | 1280h |  | 89,600 | 89,600 |  |
| 7 | 1.1.5 | Order circuit boards | 5d | 2011-06-24 | 2011-06-30 | 26 |  |  | 2011-06-30 | 2011-07-07 | 5d | 5d | 0d | Purchasing | 40h |  | 1,600 | 1,600 |  |
| 8 | 1.1.6 | Assemble preproduction models | 30d | 2011-09-13 | 2011-10-24 | 7FS+50d |  |  | 2011-09-19 | 2011-10-28 | 30d | 5d |  | Assembly/test; Development | 480h |  | 33,600 | 33,600 |  |
| 9 | 1.2 | **Operating system** | 441d | 2010-02-08 A | 2011-10-31 |  | 14% | 378.97d | 2010-02-08 | 2011-11-04 | 445d | 0d |  |  | 4600h | 720h | 331,200 | 333,600 | 58,480 |
| 10 | 1.2.1 | Kernel specifications | 25d | 2010-02-08 A | 2010-03-12 A | 24 | 100% |  | 2010-02-08 | 2010-03-05 | 20d |  |  | Design | 200h | 200h | 20,000 | 16,000 | 20,000 |
| 11 | 1.2.2 | **Drivers** | 301d | 2010-03-15 A | 2011-05-18 |  | 6% | 283.99d | 2010-03-08 | 2011-05-24 | 310d | 0d |  |  | 2640h | 208h | 184,800 | 184,800 | 14,560 |
| 12 | 1.2.2.1 | Disk drivers | 100d | 2010-03-15 A | 2010-08-03 | 10 | 13% | 87d | 2010-03-08 | 2010-07-27 | 100d | 21d |  | Assembly/test; Development | 1600h | 208h | 112,000 | 112,000 | 14,560 |
| 13 | 1.2.2.2 | Serial I/O drivers | 130d | 2010-11-12 | 2011-05-18 | 25 |  |  | 2010-11-18 | 2011-05-24 | 130d | 0d |  | Development | 1040h |  | 72,800 | 72,800 |  |
| 14 | 1.2.3 | Memory management | 90d | 2010-03-15 A | 2010-07-20 | 10 | 14% | 77d | 2010-03-08 | 2010-07-13 | 90d | 31d |  | Development | 720h | 104h | 50,400 | 50,400 | 7,280 |
| 15 | 1.2.4 | Operating system documentation | 20d | 2010-03-15 A | 2010-04-09 | 10 | 65% | 7d | 2010-03-29 | 2010-04-30 | 25d | 101d |  | Design; Decumentation | 320h | 208h | 25,600 | 32,000 | 16,640 |
| 16 | 1.2.5 | Network interface | 90d | 2011-06-24 | 2011-10-31 | 26 |  |  | 2011-06-30 | 2011-11-04 | 90d | 0d |  | Development | 720h |  | 50,400 | 50,400 |  |
| 17 | 1.3 | **Utilities** | 391d | 2010-03-08 A | 2011-09-19 |  | 7% | 362.04d | 2010-03-08 | 2011-09-23 | 395d | 30d |  |  | 2232h | 272h | 187,280 | 182,000 | 22,880 |
| 18 | 1.3.1 | Utilities specifications | 16d | 2010-03-08 A | 2010-03-29 A | 24 | 100% |  | 2010-03-08 | 2010-03-26 | 15d |  |  | Development; Design | 256h | 256h | 21,760 | 20,400 | 21,760 |
| 19 | 1.3.2 | Routine utilities | 60d | 2010-03-30 | 2010-06-22 | 18 |  |  | 2010-03-29 | 2010-06-21 | 60d | 50d |  | Xdevelopment | 480h |  | 57,600 | 57,600 |  |
| 20 | 1.3.3 | Complex utilities | 87d | 2010-03-30 A | 2010-07-30 | 18 | 2% | 85d | 2010-03-29 | 2010-07-20 | 80d | 23d |  | Development | 696h | 16h | 48,720 | 44,800 | 1,120 |
| 21 | 1.3.4 | Utilities documentation | 20d | 2010-05-04 | 2010-06-01 | 18 |  |  | 2010-05-03 | 2010-05-28 | 20d | 65d |  | Decumentation; Design | 320h |  | 25,600 | 25,600 |  |
| 22 | 1.3.5 | Shell | 60d | 2011-06-24 | 2011-09-19 | 26 |  |  | 2011-06-30 | 2011-09-23 | 60d | 30d |  | Development | 480h |  | 33,600 | 33,600 |  |
| 23 | 1.4 | **System integration** | 526d | 2010-01-04 A | 2012-01-27 |  | 12% | 463.38d | 2010-01-04 | 2012-02-02 | 530d | 0d |  |  | 2960h | 200h | 209,200 | 209,200 | 20,000 |
| 24 | 1.4.1 | Architectural decisions | 25d | 2010-01-04 A | 2010-02-05 A |  | 100% |  | 2010-01-04 | 2010-02-05 | 25d |  |  | Design | 200h | 200h | 20,000 | 20,000 | 20,000 |
| 25 | 1.4.2 | Integration first phase | 50d | 2010-09-02 | 2010-11-11 | 5, 12, 14, 15, 19, 20, 21 |  |  | 2010-09-09 | 2010-11-17 | 50d | 0d |  | Assembly/test; Development | 800h |  | 56,000 | 56,000 |  |
| 26 | 1.4.3 | System hard/software test | 25d | 2011-05-19 | 2011-06-23 | 6, 13 |  |  | 2011-05-25 | 2011-06-29 | 25d | 0d |  | Assembly/test | 200h |  | 14,000 | 14,000 |  |
| 27 | 1.4.4 | Project documentation | 50d | 2011-06-24 | 2011-09-02 | 26 |  |  | 2011-06-30 | 2011-09-09 | 50d | 40d |  | Decumentation; Development | 800h |  | 52,000 | 52,000 |  |
| 28 | 1.4.5 | Integration acceptance testing | 60d | 2011-11-01 | 2012-01-27 | 8, 16, 22, 27 |  |  | 2011-11-07 | 2012-02-02 | 60d | 0d |  | Assembly/test; Development | 960h |  | 67,200 | 67,200 |  |
