# CBP_2010_P3A_Outside_Slack

Schedule from MS Project, 2010-01-04 to 2012-01-24, status date 2010-07-01, costs in $, A marks actual dates.
Home

## Calendars

- Standard: Mon-Fri 08:00-12:00, 13:00-17:00; Sat-Sun off. Exceptions (off unless hours are given): 2010-05-31, 2010-07-04 to 2010-07-05, 2010-09-06, 2010-11-25, 2010-12-24 to 2010-12-27, 2011-01-01, 2011-01-03, 2011-05-30, 2011-07-04, 2011-09-05, 2011-11-24, 2011-12-25 to 2011-12-27, 2012-01-01 to 2012-01-02.

## Resources

| Resource | Rate |
| --- | --- |
| Design | 100 |
| Development | 70 |
| Decumentation | 60 |
| Assembly/test | 70 |
| Purchasing | 40 |
| XDevelopment | 120 |

## Schedule

| ID | WBS | Task | Duration | Start | Finish | Predecessors | Complete | Remaining | Baseline start | Baseline finish | Baseline duration | Total slack | Free slack | Resources | Work | Actual work | Cost | Baseline cost | Actual cost |
| --- | --- | --- | --- | --- | --- | --- | --- | --- | --- | --- | --- | --- | --- | --- | --- | --- | --- | --- | --- |
| 1 | 1 | **Conveyor Belt Project** | 523d | 2010-01-04 A | 2012-01-24 |  | 40% | 312.84d | 2010-01-04 | 2012-02-02 | 530d | 0d |  |  | 14256h | 5776h | 1,073,760 | 1,051,200 | 470,720 |
| 2 | 1.1 | **Hardware** | 432d | 2010-02-09 A | 2011-10-19 |  | 39% | 262.23d | 2010-02-08 | 2011-10-28 | 440d | 5d |  |  | 4072h | 1616h | 315,520 | 326,400 | 137,360 |
| 3 | 1.1.1 | Hardware specifications | 45d | 2010-02-09 A | 2010-04-12 A | 24 | 100% |  | 2010-02-08 | 2010-04-16 | 50d |  |  | Development; Design | 720h | 720h | 61,200 | 68,000 | 61,200 |
| 4 | 1.1.2 | Hardware design | 67d | 2010-04-13 A | 2010-07-16 | 3 | 84% | 11d | 2010-04-19 | 2010-07-27 | 70d | 0d |  | Design; Development | 1072h | 896h | 91,120 | 95,200 | 76,160 |
| 5 | 1.1.3 | Hardware documentation | 30d | 2010-07-19 | 2010-08-27 | 4 |  |  | 2010-07-28 | 2010-09-08 | 30d | 0d |  | Decumentation; Design | 480h |  | 38,400 | 38,400 |  |
| 6 | 1.1.4 | Prototypes | 80d | 2010-11-09 | 2011-03-04 | 25 |  |  | 2010-11-18 | 2011-03-15 | 80d | 50d |  | Assembly/test; Development | 1280h |  | 89,600 | 89,600 |  |
| 7 | 1.1.5 | Order circuit boards | 5d | 2011-06-21 | 2011-06-27 | 26 |  |  | 2011-06-30 | 2011-07-07 | 5d | 5d | 0d | Purchasing | 40h |  | 1,600 | 1,600 |  |
| 8 | 1.1.6 | Assemble preproduction models | 30d | 2011-09-08 | 2011-10-19 | 7FS+50d |  |  | 2011-09-19 | 2011-10-28 | 30d | 5d |  | Assembly/test; Development | 480h |  | 33,600 | 33,600 |  |
| 9 | 1.2 | **Operating system** | 438d | 2010-02-08 A | 2011-10-26 |  | 43% | 250.29d | 2010-02-08 | 2011-11-04 | 445d | 0d |  |  | 4888h | 2448h | 352,160 | 333,600 | 181,360 |
| 10 | 1.2.1 | Kernel specifications | 25d | 2010-02-08 A | 2010-03-12 A | 24 | 100% |  | 2010-02-08 | 2010-03-05 | 20d |  |  | Design | 200h | 200h | 20,000 | 16,000 | 20,000 |
| 11 | 1.2.2 | **Drivers** | 298d | 2010-03-15 A | 2011-05-13 |  | 32% | 202.39d | 2010-03-08 | 2011-05-24 | 310d | 0d |  |  | 2800h | 1232h | 196,000 | 184,800 | 86,240 |
| 12 | 1.2.2.1 | Disk drivers | 110d | 2010-03-15 A | 2010-08-17 | 10 | 70% | 33d | 2010-03-08 | 2010-07-27 | 100d | 8d |  | Assembly/test; Development | 1760h | 1232h | 123,200 | 112,000 | 86,240 |
| 13 | 1.2.2.2 | Serial I/O drivers | 130d | 2010-11-09 | 2011-05-13 | 25 |  |  | 2010-11-18 | 2011-05-24 | 130d | 0d |  | Development | 1040h |  | 72,800 | 72,800 |  |
| 14 | 1.2.3 | Memory management | 96d | 2010-03-15 A | 2010-07-28 | 10 | 80% | 19d | 2010-03-08 | 2010-07-13 | 90d | 22d |  | Development | 768h | 616h | 53,760 | 50,400 | 43,120 |
| 15 | 1.2.4 | Operating system documentation | 25d | 2010-03-15 A | 2010-04-16 A | 10 | 100% |  | 2010-03-29 | 2010-04-30 | 25d |  |  | Design; Decumentation | 400h | 400h | 32,000 | 32,000 | 32,000 |
| 16 | 1.2.5 | Network interface | 90d | 2011-06-21 | 2011-10-26 | 26 |  |  | 2011-06-30 | 2011-11-04 | 90d | 0d |  | Development | 720h |  | 50,400 | 50,400 |  |
| 17 | 1.3 | **Utilities** | 388d | 2010-03-08 A | 2011-09-14 |  | 59% | 157.34d | 2010-03-08 | 2011-09-23 | 395d | 30d |  |  | 2336h | 1512h | 196,880 | 182,000 | 132,000 |
| 18 | 1.3.1 | Utilities specifications | 16d | 2010-03-08 A | 2010-03-29 A | 24 | 100% |  | 2010-03-08 | 2010-03-26 | 15d |  |  | Development; Design | 256h | 256h | 21,760 | 20,400 | 21,760 |
| 19 | 1.3.2 | Routine utilities | 65d | 2010-04-26 A | 2010-07-27 | 18 | 72% | 18d | 2010-03-29 | 2010-06-21 | 60d | 23d |  | XDevelopment | 520h | 376h | 62,400 | 57,600 | 45,120 |
| 20 | 1.3.3 | Complex utilities | 91d | 2010-03-30 A | 2010-08-05 | 18 | 73% | 25d | 2010-03-29 | 2010-07-20 | 80d | 16d |  | Development | 728h | 528h | 50,960 | 44,800 | 36,960 |
| 21 | 1.3.4 | Utilities documentation | 22d | 2010-05-03 A | 2010-06-02 A | 18 | 100% |  | 2010-05-03 | 2010-05-28 | 20d |  |  | Decumentation; Design | 352h | 352h | 28,160 | 25,600 | 28,160 |
| 22 | 1.3.5 | Shell | 60d | 2011-06-21 | 2011-09-14 | 26 |  |  | 2011-06-30 | 2011-09-23 | 60d | 30d |  | Development | 480h |  | 33,600 | 33,600 |  |
| 23 | 1.4 | **System integration** | 523d | 2010-01-04 A | 2012-01-24 |  | 12% | 460.74d | 2010-01-04 | 2012-02-02 | 530d | 0d |  |  | 2960h | 200h | 209,200 | 209,200 | 20,000 |
| 24 | 1.4.1 | Architectural decisions | 25d | 2010-01-04 A | 2010-02-05 A |  | 100% |  | 2010-01-04 | 2010-02-05 | 25d |  |  | Design | 200h | 200h | 20,000 | 20,000 | 20,000 |
| 25 | 1.4.2 | Integration first phase | 50d | 2010-08-30 | 2010-11-08 | 5, 12, 14, 15, 19, 20, 21 |  |  | 2010-09-09 | 2010-11-17 | 50d | 0d |  | Assembly/test; Development | 800h |  | 56,000 | 56,000 |  |
| 26 | 1.4.3 | System hard/software test | 25d | 2011-05-16 | 2011-06-20 | 6, 13 |  |  | 2011-05-25 | 2011-06-29 | 25d | 0d |  | Assembly/test | 200h |  | 14,000 | 14,000 |  |
| 27 | 1.4.4 | Project documentation | 50d | 2011-06-21 | 2011-08-30 | 26 |  |  | 2011-06-30 | 2011-09-09 | 50d | 40d |  | Decumentation; Development | 800h |  | 52,000 | 52,000 |  |
| 28 | 1.4.5 | Integration acceptance testing | 60d | 2011-10-27 | 2012-01-24 | 8, 16, 22, 27 |  |  | 2011-11-07 | 2012-02-02 | 60d | 0d |  | Assembly/test; Development | 960h |  | 67,200 | 67,200 |  |
