# Week6_Part3

Schedule from MS Project, 2010-01-04 to 2012-02-27, status date 2011-01-01, costs in $, A marks actual dates.
Microsoft

## Calendars

- Standard: Mon-Fri 08:00-12:00, 13:00-17:00; Sat-Sun off. Exceptions (off unless hours are given): 2010-05-31, 2010-07-04 to 2010-07-05, 2010-09-06, 2010-11-25, 2010-12-24 to 2010-12-27, 2011-01-01, 2011-01-03, 2011-05-30, 2011-07-04, 2011-09-05, 2011-11-24, 2011-12-25 to 2011-12-27, 2012-01-01.

## Resources

| Resource | Rate |
| --- | --- |
| Design | 100 |
| documentation | 60 |
| development | 70 |
| Assembly | 70 |
| Purchasing | 40 |
| Internal development | 60 |
| DevelopmentX | 120 |

## Schedule

| ID | WBS | Task | Type | Duration | Start | Finish | Predecessors | Complete | Remaining | Baseline start | Baseline finish | Baseline duration | Total slack | Free slack | Constraint | Resources | Work | Actual work | Cost | Baseline cost | Actual cost |
| --- | --- | --- | --- | --- | --- | --- | --- | --- | --- | --- | --- | --- | --- | --- | --- | --- | --- | --- | --- | --- | --- |
| 1 | 1 | **Conveyor Belt Project** |  | 548d | 2010-01-04 A | 2012-02-27 |  | 60% | 216.78d | 2010-01-04 | 2012-02-01 | 530d | 0d |  |  |  | 14272h | 8936h | 1,071,520 | 1,051,200 | 722,320 |
| 2 | 1.1 | **Hardware** |  | 457d | 2010-02-09 A | 2011-11-23 |  | 69% | 143.27d | 2010-02-08 | 2011-10-28 | 440d | 5d |  |  |  | 3992h | 2768h | 303,440 | 320,000 | 221,360 |
| 3 | 1.1.1 | Hardware Specifications |  | 45d | 2010-02-09 A | 2010-04-12 A | 24 | 100% |  | 2010-02-08 | 2010-04-16 | 50d |  |  |  | Design; Internal development | 720h | 720h | 57,600 | 64,000 | 57,600 |
| 4 | 1.1.2 | Hardware Design |  | 67d | 2010-04-13 A | 2010-07-16 A | 3 | 100% |  | 2010-04-19 | 2010-07-27 | 70d |  |  |  | Design; development | 1072h | 1072h | 91,120 | 95,200 | 91,120 |
| 5 | 1.1.3 | hardware documentation |  | 27d | 2010-07-19 A | 2010-08-24 A | 4 | 100% |  | 2010-07-28 | 2010-09-08 | 30d |  |  |  | documentation; Design | 432h | 432h | 34,560 | 38,400 | 34,560 |
| 6 | 1.1.4 | prototypes |  | 78d | 2010-11-11 A | 2011-03-04 | 25 | 44% | 44d | 2010-11-18 | 2011-03-15 | 80d | 75d |  |  | Assembly; development | 1248h | 544h | 87,360 | 89,600 | 38,080 |
| 7 | 1.1.5 | order circuit boards |  | 5d | 2011-07-27 | 2011-08-02 | 26 |  |  | 2011-06-30 | 2011-07-07 | 5d | 5d | 0d |  | Purchasing | 40h |  | 1,600 | 1,600 |  |
| 8 | 1.1.6 | assemble preproduction models |  | 30d | 2011-10-13 | 2011-11-23 | 7FS+50d |  |  | 2011-09-19 | 2011-10-28 | 30d | 5d |  |  | Assembly; Internal development | 480h |  | 31,200 | 31,200 |  |
| 9 | 1.2 | **operating systems** |  | 463d | 2010-02-08 A | 2011-12-01 |  | 58% | 193.15d | 2010-03-09 | 2011-11-04 | 424d | 0d |  |  |  | 5088h | 3416h | 337,920 | 308,000 | 237,600 |
| 10 | 1.2.1 | kernel specifications | manual | 25d | 2010-02-08 A | 2010-03-12 A | 24 | 100% |  | 2010-03-09 | 2010-04-05 | 20d |  |  | start no earlier than 2010-02-08 | Design | 200h | 200h | 20,000 | 16,000 | 20,000 |
| 11 | 1.2.2 | **drivers** |  | 323d | 2010-03-15 A | 2011-06-20 |  | 55% | 146.15d | 2010-04-06 | 2011-05-24 | 289d | 0d |  |  |  | 2984h | 2032h | 187,840 | 166,400 | 130,720 |
| 12 | 1.2.2.1 | disk drivers |  | 110d | 2010-03-15 A | 2010-08-17 A | 10 | 100% |  | 2010-04-06 | 2010-08-25 | 100d |  |  | finish no earlier than 2010-08-17 | Assembly; Internal development | 1760h | 1760h | 114,400 | 104,000 | 114,400 |
| 13 | 1.2.2.2 | serial I/O drivers |  | 153d | 2010-11-11 A | 2011-06-20 | 25 | 22% | 119d | 2010-11-18 | 2011-05-24 | 130d | 0d |  |  | Internal development | 1224h | 272h | 73,440 | 62,400 | 16,320 |
| 14 | 1.2.3 | memory management |  | 98d | 2010-03-15 A | 2010-07-30 A | 10 | 100% |  | 2010-04-06 | 2010-08-11 | 90d |  |  | finish no earlier than 2010-07-30 | development | 784h | 784h | 54,880 | 50,400 | 54,880 |
| 15 | 1.2.4 | operating system documentation |  | 25d | 2010-03-15 A | 2010-04-16 A | 10 | 100% |  | 2010-04-06 | 2010-05-10 | 25d |  |  |  | Design; documentation | 400h | 400h | 32,000 | 32,000 | 32,000 |
| 16 | 1.2.5 | network interface |  | 90d | 2011-07-27 | 2011-12-01 | 26 |  |  | 2011-06-30 | 2011-11-04 | 90d | 0d |  |  | Internal development | 720h |  | 43,200 | 43,200 |  |
| 17 | 1.3 | **utilities** |  | 418d | 2010-03-01 A | 2011-10-19 |  | 76% | 99.13d | 2010-02-08 | 2011-09-23 | 415d | 30d |  |  |  | 2152h | 1672h | 215,360 | 214,000 | 181,760 |
| 18 | 1.3.1 | utilities specifications |  | 16d | 2010-03-08 A | 2010-03-29 A | 24 | 100% |  | 2010-02-08 | 2010-02-26 | 15d |  |  | finish no earlier than 2010-03-29 | Design; development | 256h | 256h | 21,760 | 20,400 | 21,760 |
| 19 | 1.3.2 | routine utilities |  | 60d | 2010-03-01 A | 2010-05-21 A | 18 | 100% |  | 2010-03-01 | 2010-05-21 | 60d |  |  |  | DevelopmentX | 480h | 480h | 57,600 | 57,600 | 57,600 |
| 20 | 1.3.3 | complex utilities |  | 95d | 2010-03-30 A | 2010-08-11 A | 18 | 100% |  | 2010-03-01 | 2010-06-21 | 80d |  |  | finish no earlier than 2010-08-11 | DevelopmentX | 760h | 760h | 91,200 | 76,800 | 91,200 |
| 21 | 1.3.4 | utilities documentation |  | 22d | 2010-05-03 A | 2010-06-04 A | 18 | 100% |  | 2010-03-01 | 2010-06-08 | 40d |  |  |  | documentation; Design | 176h | 176h | 11,200 | 25,600 | 11,200 |
| 22 | 1.3.5 | shell |  | 60d | 2011-07-27 | 2011-10-19 | 26 |  |  | 2011-06-30 | 2011-09-23 | 60d | 30d |  |  | development | 480h |  | 33,600 | 33,600 |  |
| 23 | 1.4 | **system integration** |  | 548d | 2010-01-04 A | 2012-02-27 |  | 37% | 344.09d | 2010-01-04 | 2012-02-01 | 530d | 0d |  |  |  | 3040h | 1080h | 214,800 | 209,200 | 81,600 |
| 24 | 1.4.1 | architectural decisions |  | 25d | 2010-01-04 A | 2010-02-05 A |  | 100% |  | 2010-01-04 | 2010-02-05 | 25d |  |  |  | Design | 200h | 200h | 20,000 | 20,000 | 20,000 |
| 25 | 1.4.2 | Integration first phase |  | 55d | 2010-08-25 A | 2010-11-10 A | 12, 15, 19, 20, 21, 5, 14 | 100% |  | 2010-09-09 | 2010-11-17 | 50d |  |  | finish no earlier than 2010-11-10 | Assembly; development | 880h | 880h | 61,600 | 56,000 | 61,600 |
| 26 | 1.4.3 | system hard/software test |  | 25d | 2011-06-21 | 2011-07-26 | 6, 13 |  |  | 2011-05-25 | 2011-06-29 | 25d | 0d |  |  | Assembly | 200h |  | 14,000 | 14,000 |  |
| 27 | 1.4.4 | project documentation |  | 50d | 2011-07-27 | 2011-10-05 | 26 |  |  | 2011-06-30 | 2011-09-09 | 50d | 40d |  |  | documentation; development | 800h |  | 52,000 | 52,000 |  |
| 28 | 1.4.5 | integration acceptance testing |  | 60d | 2011-12-02 | 2012-02-27 | 8, 16, 22, 27 |  |  | 2011-11-07 | 2012-02-01 | 60d | 0d |  |  | Assembly; development | 960h |  | 67,200 | 67,200 |  |
