# Conveyor Blet

Schedule from MS Project, 2010-01-04 to 2011-12-28.

## Calendars

- Standard: Mon-Fri 08:00-12:00, 13:00-17:00; Sat-Sun off. Exceptions (off unless hours are given): 2010-05-31 (Memorial Day), 2010-07-04 (Fourth of July), 2010-07-05 (Employee Holiday (Day after Fourth of July)), 2010-09-06 (Labor Day), 2010-11-25 (Thanksgiving), 2010-12-24 (Christmas Eve), 2010-12-25 (Christmas Day), 2010-12-26 (Day after Christmas), 2010-12-27 (Employee Holiday (Monday)), 2010-12-31 (New Years Eve), 2011-01-01 (New Years Day), 2011-05-30 (Memorial Day), 2011-07-04 (Fourth of July), 2011-09-05 (Labor Day), 2011-11-24 (Thanksgiving), 2011-12-25 (Christmas), 2011-12-26 (Day After Christmas).

## Resources

| Resource |
| --- |
| Design |
| Development |
| Assembly |
| Documentation |
| Purchasing |

## Schedule

| ID | WBS | Task | Duration | Start | Finish | Predecessors | Total slack | Free slack | Resources | Work |
| --- | --- | --- | --- | --- | --- | --- | --- | --- | --- | --- |
| 1 | CBP01 | **Compterized Conveyor Belt** | 505d | 2010-01-04 | 2011-12-28 |  | -390d | 0d |  | 14360h |
| 2 | CBP01.01 | **Hardware** | 50d | 2010-01-04 | 2010-03-15 | 24 |  |  | Development; Design | 4600h |
| 3 | CBP01.01.01 | Hardware Specifications | 25d | 2010-02-08 | 2010-03-15 | 24 | -390d | 0d | Design; Development | 400h |
| 4 | CBP01.01.02 | Hardware Design | 70d | 2010-03-15 | 2010-06-22 | 3 | -390d | 0d | Design; Development | 1120h |
| 5 | CBP01.01.03 | Hardware Documentation | 30d | 2010-06-22 | 2010-08-04 | 4 | -390d | 0d | Documentation; Design | 480h |
| 6 | CBP01.01.04 | Prototypes | 80d | 2010-10-14 | 2011-02-09 | 25 | -340d | 0d | Assembly; Development | 1280h |
| 7 | CBP01.01.05 | Order Circuit Boards | 5d | 2011-05-25 | 2011-06-02 | 26 | -390d | 0d | Purchasing | 40h |
| 8 | CBP01.01.06 | Assemble Pre Production Models | 30d | 2011-08-12 | 2011-09-26 | 7FS+50d | -390d | 0d | Assembly; Development | 480h |
| 9 | CBP01.02 | **Operating System** | 420d | 2010-02-08 | 2011-10-03 |  | -385d | 0d |  | 4640h |
| 10 | CBP01.02.01 | Kernel Specifications | 20d | 2010-02-08 | 2010-03-08 | 24 | -385d | 0d | Design | 160h |
| 11 | CBP01.02.02 | **Drivers** | 285d | 2010-03-08 | 2011-04-20 |  | -390d | 0d |  | 2640h |
| 12 | CBP01.02.02.1 | Disk Drivers | 100d | 2010-03-08 | 2010-07-28 | 10 | -385d | 0d | Assembly; Development | 1600h |
| 13 | CBP01.02.02.2 | Serial I/O Drivers | 130d | 2010-10-14 | 2011-04-20 | 25 | -390d | 0d | Development | 1040h |
| 14 | CBP01.02.03 | Memory Management | 90d | 2010-03-08 | 2010-07-14 | 10 | -375d | 0d | Development | 720h |
| 15 | CBP01.02.04 | Operating System Documentation | 25d | 2010-03-08 | 2010-04-12 | 10 | -310d | 0d | Design; Documentation | 400h |
| 16 | CBP01.02.05 | Network Interface | 90d | 2011-05-25 | 2011-10-03 | 26 | 0d |  | Development | 720h |
| 17 | CBP01.03 | **Utilities** | 390d | 2010-02-08 | 2011-08-19 |  | -360d | 0d |  | 2160h |
| 18 | CBP01.03.01 | Utilities Specifications | 15d | 2010-02-08 | 2010-03-01 | 24 | -360d | 0d | Development; Design | 240h |
| 19 | CBP01.03.02 | Routine Utilities | 60d | 2010-03-01 | 2010-05-24 | 18 | -340d | 0d | Development | 480h |
| 20 | CBP01.03.03 | Complex Utilities | 80d | 2010-03-01 | 2010-06-22 | 18 | -360d | 0d | Development | 640h |
| 21 | CBP01.03.04 | Utilities Documentation | 20d | 2010-03-01 | 2010-03-29 | 18 | -300d | 0d | Documentation; Design | 320h |
| 22 | CBP01.03.05 | Shell | 60d | 2011-05-25 | 2011-08-19 | 26 | 30d |  | Development | 480h |
| 23 | CBP01.04 | **System Intergration** | 505d | 2010-01-04 | 2011-12-28 |  | -390d | 0d |  | 2960h |
| 24 | CBP01.04.01 | Architectural Decisions | 25d | 2010-01-04 | 2010-02-08 |  | -390d | 0d | Design | 200h |
| 25 | CBP01.04.02 | Intergration First Phase | 50d | 2010-08-04 | 2010-10-14 | 12, 14, 15, 19, 20, 21, 5 | -390d | 0d | Assembly; Development | 800h |
| 26 | CBP01.04.03 | System Hard/Software Test | 25d | 2011-04-20 | 2011-05-25 | 6, 13 | -390d | 0d | Assembly | 200h |
| 27 | CBP01.04.04 | Project Documentation | 50d | 2011-05-25 | 2011-08-05 | 26 | 40d |  | Documentation; Development | 800h |
| 28 | CBP01.04.05 | Intergration Acceptance Testing | 60d | 2011-10-03 | 2011-12-28 | 16, 22, 27, 8 | 0d |  | Assembly; Development | 960h |
