# Conveyor Belt Project

Schedule from MS Project, 2010-01-04 to 2012-01-23, costs in $.
CSC @ BIW

## Calendars

- Standard: Mon-Fri 08:00-12:00, 13:00-17:00; Sat-Sun off. Exceptions (off unless hours are given): 2010-05-24 (Memorial Day), 2010-07-05 (July Fourth), 2010-09-06 (Labor Day), 2010-11-25 (Thanksgiving), 2010-12-24 to 2010-12-27 (Christmas).

## Resources

| Resource | Rate |
| --- | --- |
| Design | 1 |
| Development | 1 |
| Assembly | 1 |
| Documentation | 1 |
| Purchasing | 1 |

## Schedule

| ID | WBS | Task | Type | Duration | Start | Finish | Predecessors | Total slack | Free slack | Resources | Work | Cost |
| --- | --- | --- | --- | --- | --- | --- | --- | --- | --- | --- | --- | --- |
| 1 | 1 | Begin Conveyor Belt Project | milestone | 0d | 2010-01-04 | 2010-01-04 |  | 0d |  |  |  |  |
| 2 | 2 | **System Integration** |  | 530d | 2010-01-04 | 2012-01-23 |  | 0d |  |  | 3440h | 3,440 |
| 3 | 2.1 | Architectural Decisions |  | 25d | 2010-01-04 | 2010-02-05 | 1 | 0d |  | Design | 200h | 200 |
| 4 | 2.2 | Integration First Phase |  | 50d | 2010-09-09 | 2010-11-17 | 31, 32, 15, 23, 25, 26 | 0d |  | Assembly; Development | 800h | 800 |
| 5 | 2.3 | Integration Phase Complete | milestone | 0d | 2010-11-17 | 2010-11-17 | 4FF | 305d |  |  |  |  |
| 6 | 2.4 | System Hard/Software Test |  | 25d | 2011-05-24 | 2011-06-27 | 16, 24 | 0d |  | Assembly | 200h | 200 |
| 7 | 2.5 | System Test Complete | milestone | 0d | 2011-06-27 | 2011-06-27 | 6FF | 30d | 0d |  |  |  |
| 8 | 2.6 | Shell |  | 60d | 2011-06-28 | 2011-09-19 | 7 | 30d |  | Development | 480h | 480 |
| 9 | 2.7 | Project Documentation |  | 50d | 2011-06-28 | 2011-09-05 | 6 | 40d |  | Documentation; Development | 800h | 800 |
| 10 | 2.8 | Integrated Acceptance Testing |  | 60d | 2011-11-01 | 2012-01-23 | 8, 9, 18, 27 | 0d |  | Assembly; Development | 960h | 960 |
| 11 | 2.9 | Integrated Testing Complete | milestone | 0d | 2012-01-23 | 2012-01-23 | 10FF | 0d |  |  |  |  |
| 12 | 3 | **Hardware** |  | 440d | 2010-02-08 | 2011-10-24 |  | 0d |  |  | 3800h | 3,800 |
| 13 | 3.1 | Hardware Specifications |  | 50d | 2010-02-08 | 2010-04-16 | 3 | 0d |  | Development | 400h | 400 |
| 14 | 3.2 | Hardware Design |  | 70d | 2010-04-19 | 2010-07-27 | 13 | 0d |  | Development; Design | 1120h | 1,120 |
| 15 | 3.3 | Hardware Documentation |  | 30d | 2010-07-28 | 2010-09-08 | 14 | 0d |  | Documentation; Design | 480h | 480 |
| 16 | 3.4 | Prototypes |  | 80d | 2010-11-18 | 2011-03-14 | 4 | 50d |  | Assembly; Development | 1280h | 1,280 |
| 17 | 3.5 | Order Circuit Boards |  | 5d | 2011-06-28 | 2011-07-04 | 6 | 5d | 0d | Purchasing | 40h | 40 |
| 18 | 3.6 | Assemble Pre-Production Models |  | 30d | 2011-09-13 | 2011-10-24 | 17FS+50d | 5d | 0d | Assembly; Development | 480h | 480 |
| 19 | 3.7 | Hardware Complete | milestone | 0d | 2011-10-24 | 2011-10-24 | 13FF, 14FF, 15FF, 16FF, 17FF, 18FF | 65d |  |  |  |  |
| 20 | 4 | **Operating System** |  | 445d | 2010-02-08 | 2011-10-31 |  | 30d |  |  | 4640h | 4,640 |
| 21 | 4.1 | Kernel Specifications |  | 20d | 2010-02-08 | 2010-03-05 | 3 | 30d | 0d | Design | 160h | 160 |
| 22 | 4.2 | **Drivers** |  | 310d | 2010-03-08 | 2011-05-23 |  | 0d |  |  | 2640h | 2,640 |
| 23 | 4.2.1 | Disk Drivers |  | 100d | 2010-03-08 | 2010-07-27 | 21 | 30d |  | Assembly; Development | 1600h | 1,600 |
| 24 | 4.2.2 | Serial I/O Drivers |  | 130d | 2010-11-18 | 2011-05-23 | 4 | 0d |  | Development | 1040h | 1,040 |
| 25 | 4.3 | Memory Management |  | 90d | 2010-03-08 | 2010-07-13 | 21 | 40d |  | Development | 720h | 720 |
| 26 | 4.4 | Operating System Documentation |  | 25d | 2010-03-08 | 2010-04-09 | 21 | 105d |  | Design; Documentation | 400h | 400 |
| 27 | 4.5 | Network Interface |  | 90d | 2011-06-28 | 2011-10-31 | 6 | 0d |  | Development | 720h | 720 |
| 28 | 4.6 | Operating System Complete | milestone | 0d | 2011-10-31 | 2011-10-31 | 21FF, 23FF, 24FF, 25FF, 26FF, 27FF | 60d |  |  |  |  |

| ID | WBS | Task | Type | Duration | Start | Finish | Predecessors | Total slack | Free slack | Resources | Work | Cost |
| --- | --- | --- | --- | --- | --- | --- | --- | --- | --- | --- | --- | --- |
| 29 | 5 | **Utilities** |  | 95d | 2010-02-08 | 2010-06-21 |  | 55d |  |  | 1680h | 1,680 |
| 30 | 5.1 | Utilities Specification |  | 15d | 2010-02-08 | 2010-02-26 | 3 | 55d | 0d | Development; Design | 240h | 240 |
| 31 | 5.2 | Routine Utilities |  | 60d | 2010-03-01 | 2010-05-21 | 30 | 75d | 20d | Development | 480h | 480 |
| 32 | 5.3 | Complex Utilities |  | 80d | 2010-03-01 | 2010-06-21 | 30 | 55d | 0d | Development | 640h | 640 |
| 33 | 5.4 | Utilities Documentation |  | 20d | 2010-03-01 | 2010-03-26 | 30 | 470d | 60d | Documentation; Design | 320h | 320 |
| 34 | 5.5 | Utilities Complete | milestone | 0d | 2010-06-21 | 2010-06-21 | 30FF, 31FF, 32FF, 33FF | 410d |  |  |  |  |
| 35 | 6 | Conveyor Belt Project Complete | milestone | 0d | 2012-01-23 | 2012-01-23 | 11FF, 19FF, 28FF, 34FF | 0d |  |  |  |  |
