# Huntsville

Schedule from MS Project, 2011-04-18 to 2012-07-06.

## Calendars

- Standard: Mon-Fri 08:00-12:00, 13:00-17:00; Sat-Sun off.

## Resources

| Resource |
| --- |
| Facility Specialist |
| Project Manager |
| Corp. Personnel |
| Production Specialist |
| Real Estate Consultant |
| Manufacturing Engineer |
| General Contractor |
| Personnel Director |
| Architect |
| Marketing Specialist |
| Accounting Director |
| Traffic Manager |
| Purchasing Agent |

## Schedule

| ID | WBS | Task | Duration | Start | Finish | Predecessors | Total slack | Free slack | Resources | Work |
| --- | --- | --- | --- | --- | --- | --- | --- | --- | --- | --- |
| 1 | 1 | **Huntsville Plant Project** | 320d? | 2011-04-18 | 2012-07-06 |  | 0d |  |  | 3800h |
| 2 | 1.1 | **PLANNING PHASE** | 50d | 2011-04-18 | 2011-06-24 |  | 0d |  |  | 1170h |
| 3 | 1.1.1 | Select Architect | 2w | 2011-04-18 | 2011-04-29 |  | 0d |  | Facility Specialist [60%]; Project Manager [10%] | 56h |
| 4 | 1.1.2 | Recruit & Train Managers | 6w | 2011-04-18 | 2011-05-27 |  | 200d | 0d | Project Manager [15%]; Corp. Personnel [80%] | 228h |
| 5 | 1.1.3 | Select Real Estate Consultant | 2w | 2011-04-18 | 2011-04-29 |  | 10d |  | Project Manager [10%]; Facility Specialist [50%] | 48h |
| 6 | 1.1.4 | Create Pre-Production Plan | 2w | 2011-04-18 | 2011-04-29 |  | 0d |  | Production Specialist [80%]; Manufacturing Engineer [85%]; Project Manager [20%] | 148h |
| 7 | 1.1.5 | Create Production Plan | 4w | 2011-05-02 | 2011-05-27 | 6 | 120d | 0d | Production Specialist [60%]; Manufacturing Engineer [80%]; Marketing Specialist [20%] | 256h |
| 8 | 1.1.6 | Establish Building Concept | 2w | 2011-05-02 | 2011-05-13 | 6, 3 | 0d |  | Facility Specialist [40%]; Architect [70%] | 88h |
| 9 | 1.1.7 | Create Building Design | 6w | 2011-05-16 | 2011-06-24 | 8 | 0d |  | Facility Specialist [20%]; Architect [10%] | 72h |
| 10 | 1.1.8 | Procure Site | 3w | 2011-05-16 | 2011-06-03 | 5, 8 | 0d |  | Real Estate Consultant [70%]; Marketing Specialist [20%]; Facility Specialist [30%] | 144h |
| 11 | 1.1.9 | Select General Contractor | 2w | 2011-05-16 | 2011-05-27 | 8 | 5d |  | Project Manager [10%]; Facility Specialist [30%]; Production Specialist [10%]; Architect [15%] | 52h |
| 12 | 1.1.10 | Obtain Permits & Approvals | 3w | 2011-06-06 | 2011-06-24 | 5, 10, 11 | 0d |  | Project Manager [10%]; Real Estate Consultant [30%]; General Contractor [10%]; Architect [15%] | 78h |
| 13 | 1.2 | **PREPARATION PHASE** | 310d? | 2011-04-18 | 2012-06-22 |  | 10d |  |  | 2558h |
| 14 | 1.2.1 | Prepare Site | 4w | 2011-06-27 | 2011-07-22 | 9, 10, 12 | 0d |  | Project Manager [20%]; Real Estate Consultant [20%]; General Contractor [20%] | 96h |
| 15 | 1.2.2 | Construct Building | 40w | 2011-07-25 | 2012-04-27 | 9, 12, 14 | 0d |  | Project Manager [10%]; Facility Specialist [20%]; General Contractor [35%] | 1040h |
| 16 | 1.2.3 | Install Landscaping | 3w | 2012-04-30 | 2012-05-18 | 15 | 35d |  | Facility Specialist [15%] | 18h |
| 17 | 1.2.4 | PLANT READINESS PHASE | 0.2w? | 2011-04-18 | 2011-04-18 |  | 319d |  |  |  |
| 18 | 1.2.5 | Recruit Plant Personnel | 8w | 2011-05-30 | 2011-07-22 | 4, 7 | 200d |  | Facility Specialist [10%]; Production Specialist [10%]; Project Manager [10%]; Marketing Specialist [10%]; Personnel Director [10%] | 160h |
| 19 | 1.2.6 | Procure Equipment | 24w | 2011-05-30 | 2011-11-11 | 7 | 120d |  | Manufacturing Engineer [40%]; Purchasing Agent [25%] | 624h |
| 20 | 1.2.7 | Procure Raw Material | 8w | 2011-05-30 | 2011-07-22 | 7 | 220d |  | Production Specialist [10%]; Manufacturing Engineer [10%]; Accounting Director [10%]; Purchasing Agent [20%] | 160h |
| 21 | 1.2.8 | Install Equipment | 4w | 2012-04-30 | 2012-05-25 | 15, 18, 19 | 0d |  | Production Specialist [10%]; Manufacturing Engineer [30%]; Facility Specialist [40%] | 128h |
| 22 | 1.2.9 | Implement Product Distribution Plan | 2w | 2011-05-30 | 2011-06-10 | 7 | 235d | 230d | Marketing Specialist [45%]; Traffic Manager [40%] | 68h |
| 23 | 1.2.10 | Procure Truck Fleet | 8w | 2012-04-30 | 2012-06-22 | 15, 22 | 5d |  | Purchasing Agent [20%]; Traffic Manager [10%]; Accounting Director [10%] | 128h |
| 24 | 1.2.11 | Perform Pre-Production Run | 4w | 2012-05-28 | 2012-06-22 | 18, 20, 21 | 0d |  | Production Specialist [15%]; Manufacturing Engineer [70%] | 136h |

| ID | WBS | Task | Duration | Start | Finish | Predecessors | Total slack | Resources | Work |
| --- | --- | --- | --- | --- | --- | --- | --- | --- | --- |
| 25 | 1.3 | **PRODUCTION PHASE** | 10d | 2012-06-25 | 2012-07-06 |  | 0d |  | 72h |
| 26 | 1.3.1 | Perform Production Start-up | 1w | 2012-06-25 | 2012-06-29 | 24 | 0d | Production Specialist [30%]; Manufacturing Engineer [70%] | 40h |
| 27 | 1.3.2 | Begin Distribution | 1w | 2012-07-02 | 2012-07-06 | 23, 26 | 0d | Marketing Specialist [20%]; Traffic Manager [60%] | 32h |
